# Habitat2

Schedule from MS Project, 2008-08-27 to 2009-02-23.
WL / Delft Hydraulics

## Calendars

- Standard: Mon-Fri 08:00-12:00, 13:00-17:00; Sat-Sun off.

## Resources

| Resource |
| --- |
| Erik |
| Onno |
| Gena |
| Paul |
| Fedor |
| Arnout |

## Schedule

| ID | WBS | Task | Duration | Start | Finish | Total slack | Constraint | Resources | Work | Text1 |
| --- | --- | --- | --- | --- | --- | --- | --- | --- | --- | --- |
| 1 | 1 | **Map control decorations** | 128.62d | 2008-08-27 | 2009-02-23 | 0d |  |  | 120h |  |
| 2 | 1.1 | North / south arrow | 0.91d | 2008-08-27 | 2008-08-27 | 127.72d | start no earlier than 2008-08-27 | Gena [10%]; Arnout | 8h | 100 |
| 3 | 1.2 | Cross-sectional profiles | 3.64d | 2008-08-28 | 2008-09-02 | 123.99d | start no earlier than 2008-08-28 | Paul [10%]; Arnout | 32h | 100 |
| 4 | 1.3 | Scale | 3d | 2008-09-02 | 2008-09-05 | 120.97d | start no earlier than 2008-09-02 | Arnout | 24h | 100 |
| 5 | 1.4 | Classificatie aanpassen (gui dialog) | 10d | 2009-02-09 | 2009-02-23 | 0d | start no earlier than 2009-02-09 | Erik [50%] | 40h |  |
| 6 | 1.5 | Opslaan en ophalen van classificatie gegevens | 4d | 2009-02-16 | 2009-02-19 | 1.62d | start no earlier than 2009-02-16 | Gena [50%] | 16h | 20 |
| 7 | 2 | **Conversie applicatie voor kaartlagen (?)** | 13d | 2009-01-21 | 2009-02-09 | 10d |  |  | 72h |  |
| 8 | 2.1 | Uitzoeken wat werkt en niet werkt voor Resample | 2d | 2009-01-21 | 2009-01-23 | 21d | start no earlier than 2009-01-21 | Erik | 16h |  |
| 9 | 2.2 | Dummy proef maken | 3d | 2009-01-23 | 2009-01-28 | 18d | start no earlier than 2009-01-23 | Erik | 24h |  |
| 10 | 2.3 | Bug fixes + overig | 8d | 2009-01-28 | 2009-02-09 | 10d | start no earlier than 2009-01-28 | Erik [50%] | 32h |  |
| 11 | 3 | **DelftShell upgrade** | 25.77d | 2009-01-05 | 2009-02-09 | 9.86d |  |  | 168h |  |
| 12 | 3.1 | Huidig opslagmechanisme doorvoeren voor Habitat | 9.33d | 2009-01-05 | 2009-01-16 | 26.29d | start no earlier than 2009-01-05 | Onno [50%]; Gena [50%] | 56h |  |
| 13 | 3.2 | Importeren oude projecten (XML > DB) | 11.67d | 2009-01-16 | 2009-02-02 | 14.96d | start no earlier than 2009-01-16 | Gena [50%]; Onno [50%] | 56h |  |
| 14 | 3.3 | Toolbox migreren naar nieuwe versie | 10.77d | 2009-01-26 | 2009-02-09 | 9.86d | start no earlier than 2009-01-26 | Onno [50%]; Gena [15%] | 56h | 50 |
| 15 | 4 | **Nieuwe functionaliteit PcRaster implementeren in Habitat** | 83d | 2008-10-01 | 2009-01-23 | 20.62d |  |  | 264h |  |
| 16 | 4.1 | Implement new GridTimeSeries data type | 15.38d | 2008-10-01 | 2008-10-22 | 88.24d | start no earlier than 2008-10-01 | Gena [50%]; Fedor [25%] | 80h | 100 |
| 17 | 4.2 | Opzetten van klassen die rasterlagen laden (GDAL/NetCDF) | 7.62d | 2008-10-27 | 2008-11-05 | 78.01d | start no earlier than 2008-10-25 | Gena [50%]; Fedor [25%]; Arnout [50%] | 40h | 100 |
| 18 | 4.3 | Tussenresultaten facultatief opslaan | 5d | 2009-01-19 | 2009-01-23 | 20.62d | start no earlier than 2009-01-19 | Onno [50%]; Gena [10%] | 24h |  |
| 19 | 4.4 | Upgrade Habitat PCRaster wrapper to a time-series grids | 17.5d | 2008-12-01 | 2008-12-24 | 43.12d | start no earlier than 2008-11-30 | Erik [50%]; Onno [20%]; Gena [10%] | 80h |  |
| 20 | 4.5 | Upgrade all Habitat forms to a new GridTimeSeries data type | 5d | 2009-01-05 | 2009-01-09 | 31d | start no earlier than 2009-01-05 | Erik | 40h |  |
| 21 | 5 | **GUI controls development / upgrade** | 7.62d | 2009-01-12 | 2009-01-21 | 23d |  |  | 64h |  |
| 22 | 5.1 | Grid time series navigation (time) control | 3.2d | 2009-01-12 | 2009-01-15 | 27.43d | start no earlier than 2009-01-12 | Gena [25%]; Erik | 32h | 100 |
| 23 | 5.2 | Chart control, upgrade from Nplot to TeeChart | 2d | 2009-01-15 | 2009-01-19 | 25.25d | start no earlier than 2009-01-15 | Erik | 16h | 100 |
| 24 | 5.3 | Table control - use XtraGrid instead of standard DataGridView | 2d | 2009-01-19 | 2009-01-21 | 23d | start no earlier than 2009-01-19 | Erik | 16h | 100 |

Notes:
- 24: Overlapping
